# Office Renovation

How a schedule from MS Project changed from version to version. A marks actual dates.

## Version 1 (saved 2024-12-18, file Lesson 5 Lead Lag.mpp)

| ID | WBS | Task | Duration | Start | Finish | Predecessors | Total float |
| --- | --- | --- | --- | --- | --- | --- | --- |
| 1 | 1 | **Planning & Research** | 9d | 2025-04-07 | 2025-04-17 |  | 0d |
| 2 |  | Develop Requirements Documentation | 1d | 2025-04-07 | 2025-04-07 |  | 0d |
| 3 |  | Fit-Out Consultant Research & Engagement | 2d | 2025-04-08 | 2025-04-09 | 2 | 0d |
| 4 |  | IT Network Contractor Research & Engagement | 2d | 2025-04-10 | 2025-04-11 | 3 | 0d |
| 5 |  | Building Contractor Research & Engagement | 2d | 2025-04-14 | 2025-04-15 | 4 | 0d |
| 6 |  | Submit Requirements to Resources & Request Quotes | 1d | 2025-04-16 | 2025-04-16 | 5 | 0d |
| 7 |  | Quotes Received | 1d | 2025-04-17 | 2025-04-17 | 6 | 0d |
| 8 |  | Planning & Research Complete | 0d | 2025-04-17 | 2025-04-17 | 7 | 0d |
| 9 | 2 | **Management Approval** | 5d | 2025-04-22 | 2025-04-29 |  | 0d |
| 10 |  | Consolidate Quotes and develop proposal | 2d | 2025-04-22 | 2025-04-23 | 8 | 0d |
| 11 |  | Develop Project Plan & Durations | 2d | 2025-04-24 | 2025-04-28 | 10 | 0d |
| 12 |  | Submit Project Plan & Costs to Management | 1d | 2025-04-29 | 2025-04-29 | 11 | 0d |
| 13 |  | Management Approval Received | 0d | 2025-04-29 | 2025-04-29 | 12 | 0d |
| 14 | 3 | **Refit Office** | 14d? | 2025-04-30 | 2025-05-20 |  | 0d |
| 15 |  | Appoint Resources | 1d | 2025-04-30 | 2025-04-30 | 13 | 0d |
| 16 |  | Staff Briefing | 1d | 2025-05-01 | 2025-05-01 | 15 | 0d |
| 17 | 3.3 | **Fit-Out Consultations** | 4d | 2025-05-02 | 2025-05-08 |  | 0d |
| 18 |  | Design office space/structure plan | 1d | 2025-05-02 | 2025-05-02 | 16 | 0d |
| 19 |  | Select & Order Carpet | 1d | 2025-05-06 | 2025-05-06 | 18 | 6d |
| 20 |  | Select & Order Paint | 1d | 2025-05-06 | 2025-05-06 | 19SS | 6d |
| 21 |  | Select & Order Office Furniture | 1d | 2025-05-07 | 2025-05-07 | 20 | 6d |
| 22 |  | Select & Order digital PBX | 1d | 2025-05-08 | 2025-05-08 | 21 | 6d |
| 23 | 3.4 | **IT consultations** | 4d | 2025-05-02 | 2025-05-08 |  | 0d |
| 24 |  | Design IT network and phone points map | 1d | 2025-05-02 | 2025-05-02 | 16 | 0d |
| 25 |  | Select & Order New PCs | 1d | 2025-05-06 | 2025-05-06 | 24 | 7d |
| 26 |  | New PCs Arrive | 0.5d | 2025-05-07 | 2025-05-07 | 25 | 7d |
| 27 |  | Configure SOE on PCs | 1.5d | 2025-05-07 | 2025-05-08 | 26 | 7d |
| 28 | 3.5 | **Refit Office** | 11d? | 2025-05-06 | 2025-05-20 |  | 0d |
| 29 |  | Erect New Walls | 2d | 2025-05-06 | 2025-05-07 | 18, 24 | 0d |
| 30 |  | Gyprock, Plaster & Finish | 2d | 2025-05-08 | 2025-05-09 | 29 | 0d |
| 31 |  | Install Network & Phone Points | 1d | 2025-05-12 | 2025-05-12 | 30 | 0d |
| 32 |  | Painting | 2d | 2025-05-13 | 2025-05-14 | 31 | 0d |
| 33 |  | Lay new carpets | 1d | 2025-05-15 | 2025-05-15 | 32 | 0d |
| 34 |  | Install PBX hardware | 1d? | 2025-05-16 | 2025-05-16 | 22, 33 | 1d |
| 35 |  | Install New Furniture | 2d | 2025-05-16 | 2025-05-19 | 21, 33 | 0d |
| 36 |  | Connect and install PCs and phones | 1d | 2025-05-20 | 2025-05-20 | 27, 34, 35 | 0d |
| 37 |  | Refit Office Complete | 0d | 2025-05-20 | 2025-05-20 | 36 | 0d |
| 38 | 4 | **Office Move** | 17d | 2025-05-02 | 2025-05-27 |  | 0d |
| 39 |  | Order packing boxes | 0.5d | 2025-05-02 | 2025-05-02 | 16 | 11.5d |
| 40 |  | Staff Pack | 1d | 2025-05-21 | 2025-05-21 | 37, 39 | 0d |
| 41 |  | Staff Move | 2d | 2025-05-22 | 2025-05-23 | 40 | 0d |
| 42 |  | Office cleaning | 2d | 2025-05-26 | 2025-05-27 | 41 | 0d |
| 43 |  | Office Move Complete | 0d | 2025-05-27 | 2025-05-27 | 42 | 0d |

## Version 2 (saved 2024-12-18, file Lesson 5 start.mpp)

Last finish 2025-05-27 → 2025-04-07 (-50d).

Changed:

| ID | Task | Start | Finish | Duration | Total float | Predecessors |
| --- | --- | --- | --- | --- | --- | --- |
| 1 | **Planning & Research** |  | 2025-04-17 → 2025-04-07 (-10d) | 9d → 1d? |  |  |
| 2 | Develop Requirements Documentation |  |  | 1d → 1d? |  |  |
| 3 | Fit-Out Consultant Research & Engagement | 2025-04-08 → 2025-04-07 (-1d) | 2025-04-09 → 2025-04-07 (-2d) | 2d → 1d? |  | 2 → none |
| 4 | IT Network Contractor Research & Engagement | 2025-04-10 → 2025-04-07 (-3d) | 2025-04-11 → 2025-04-07 (-4d) | 2d → 1d? |  | 3 → none |
| 5 | Building Contractor Research & Engagement | 2025-04-14 → 2025-04-07 (-7d) | 2025-04-15 → 2025-04-07 (-8d) | 2d → 1d? |  | 4 → none |
| 6 | Submit Requirements to Resources & Request Quotes | 2025-04-16 → 2025-04-07 (-9d) | 2025-04-16 → 2025-04-07 (-9d) | 1d → 1d? |  | 5 → none |
| 7 | Quotes Received | 2025-04-17 → 2025-04-07 (-10d) | 2025-04-17 → 2025-04-07 (-10d) | 1d → 1d? |  | 6 → none |
| 8 | Planning & Research Complete | 2025-04-17 → 2025-04-07 (-10d) | 2025-04-17 → 2025-04-07 (-10d) |  | 0d → 1d | 7 → none |
| 9 | **Management Approval** | 2025-04-22 → 2025-04-07 (-15d) | 2025-04-29 → 2025-04-07 (-22d) | 5d → 1d? |  |  |
| 10 | Consolidate Quotes and develop proposal | 2025-04-22 → 2025-04-07 (-15d) | 2025-04-23 → 2025-04-07 (-16d) | 2d → 1d? |  | 8 → none |
| 11 | Develop Project Plan & Durations | 2025-04-24 → 2025-04-07 (-17d) | 2025-04-28 → 2025-04-07 (-21d) | 2d → 1d? |  | 10 → none |
| 12 | Submit Project Plan & Costs to Management | 2025-04-29 → 2025-04-07 (-22d) | 2025-04-29 → 2025-04-07 (-22d) | 1d → 1d? |  | 11 → none |
| 13 | Management Approval Received | 2025-04-29 → 2025-04-07 (-22d) | 2025-04-29 → 2025-04-07 (-22d) |  | 0d → 1d | 12 → none |
| 14 | **Refit Office** | 2025-04-30 → 2025-04-07 (-23d) | 2025-05-20 → 2025-04-07 (-43d) | 14d? → 1d? |  |  |
| 15 | Appoint Resources | 2025-04-30 → 2025-04-07 (-23d) | 2025-04-30 → 2025-04-07 (-23d) | 1d → 1d? |  | 13 → none |
| 16 | Staff Briefing | 2025-05-01 → 2025-04-07 (-24d) | 2025-05-01 → 2025-04-07 (-24d) | 1d → 1d? |  | 15 → none |
| 17 | **Fit-Out Consultations** | 2025-05-02 → 2025-04-07 (-25d) | 2025-05-08 → 2025-04-07 (-31d) | 4d → 1d? |  |  |
| 18 | Design office space/structure plan | 2025-05-02 → 2025-04-07 (-25d) | 2025-05-02 → 2025-04-07 (-25d) | 1d → 1d? |  | 16 → none |
| 19 | Select & Order Carpet | 2025-05-06 → 2025-04-07 (-29d) | 2025-05-06 → 2025-04-07 (-29d) | 1d → 1d? | 6d → 0d | 18 → none |
| 20 | Select & Order Paint | 2025-05-06 → 2025-04-07 (-29d) | 2025-05-06 → 2025-04-07 (-29d) | 1d → 1d? | 6d → 0d | 19SS → none |
| 21 | Select & Order Office Furniture | 2025-05-07 → 2025-04-07 (-30d) | 2025-05-07 → 2025-04-07 (-30d) | 1d → 1d? | 6d → 0d | 20 → none |
| 22 | Select & Order digital PBX | 2025-05-08 → 2025-04-07 (-31d) | 2025-05-08 → 2025-04-07 (-31d) | 1d → 1d? | 6d → 0d | 21 → none |
| 23 | **IT consultations** | 2025-05-02 → 2025-04-07 (-25d) | 2025-05-08 → 2025-04-07 (-31d) | 4d → 1d? |  |  |
| 24 | Design IT network and phone points map | 2025-05-02 → 2025-04-07 (-25d) | 2025-05-02 → 2025-04-07 (-25d) | 1d → 1d? |  | 16 → none |
| 25 | Select & Order New PCs | 2025-05-06 → 2025-04-07 (-29d) | 2025-05-06 → 2025-04-07 (-29d) | 1d → 1d? | 7d → 0d | 24 → none |
| 26 | New PCs Arrive | 2025-05-07 → 2025-04-07 (-30d) | 2025-05-07 → 2025-04-07 (-30d) | 0.5d → 1d? | 7d → 0d | 25 → none |
| 27 | Configure SOE on PCs | 2025-05-07 → 2025-04-07 (-30d) | 2025-05-08 → 2025-04-07 (-31d) | 1.5d → 1d? | 7d → 0d | 26 → none |
| 28 | **Refit Office** | 2025-05-06 → 2025-04-07 (-29d) | 2025-05-20 → 2025-04-07 (-43d) | 11d? → 1d? |  |  |
| 29 | Erect New Walls | 2025-05-06 → 2025-04-07 (-29d) | 2025-05-07 → 2025-04-07 (-30d) | 2d → 1d? |  | 18, 24 → none |
| 30 | Gyprock, Plaster & Finish | 2025-05-08 → 2025-04-07 (-31d) | 2025-05-09 → 2025-04-07 (-32d) | 2d → 1d? |  | 29 → none |
| 31 | Install Network & Phone Points | 2025-05-12 → 2025-04-07 (-35d) | 2025-05-12 → 2025-04-07 (-35d) | 1d → 1d? |  | 30 → none |
| 32 | Painting | 2025-05-13 → 2025-04-07 (-36d) | 2025-05-14 → 2025-04-07 (-37d) | 2d → 1d? |  | 31 → none |
| 33 | Lay new carpets | 2025-05-15 → 2025-04-07 (-38d) | 2025-05-15 → 2025-04-07 (-38d) | 1d → 1d? |  | 32 → none |
| 34 | Install PBX hardware | 2025-05-16 → 2025-04-07 (-39d) | 2025-05-16 → 2025-04-07 (-39d) |  | 1d → 0d | 22, 33 → none |
| 35 | Install New Furniture | 2025-05-16 → 2025-04-07 (-39d) | 2025-05-19 → 2025-04-07 (-42d) | 2d → 1d? |  | 21, 33 → none |
| 36 | Connect and install PCs and phones | 2025-05-20 → 2025-04-07 (-43d) | 2025-05-20 → 2025-04-07 (-43d) | 1d → 1d? |  | 27, 34, 35 → none |
| 37 | Refit Office Complete | 2025-05-20 → 2025-04-07 (-43d) | 2025-05-20 → 2025-04-07 (-43d) |  | 0d → 1d | 36 → none |
| 38 | **Office Move** | 2025-05-02 → 2025-04-07 (-25d) | 2025-05-27 → 2025-04-07 (-50d) | 17d → 1d? |  |  |
| 39 | Order packing boxes | 2025-05-02 → 2025-04-07 (-25d) | 2025-05-02 → 2025-04-07 (-25d) | 0.5d → 1d? | 11.5d → 0d | 16 → none |
| 40 | Staff Pack | 2025-05-21 → 2025-04-07 (-44d) | 2025-05-21 → 2025-04-07 (-44d) | 1d → 1d? |  | 37, 39 → none |
| 41 | Staff Move | 2025-05-22 → 2025-04-07 (-45d) | 2025-05-23 → 2025-04-07 (-46d) | 2d → 1d? |  | 40 → none |
| 42 | Office cleaning | 2025-05-26 → 2025-04-07 (-49d) | 2025-05-27 → 2025-04-07 (-50d) | 2d → 1d? |  | 41 → none |
| 43 | Office Move Complete | 2025-05-27 → 2025-04-07 (-50d) | 2025-05-27 → 2025-04-07 (-50d) |  | 0d → 1d | 42 → none |

## Version 3 (saved 2024-12-18, file Lesson 6 Critical Path.mpp)

Last finish 2025-04-07 → 2025-06-04 (+58d).

Changed:

| ID | Task | Start | Finish | Duration | Total float | Predecessors |
| --- | --- | --- | --- | --- | --- | --- |
| 1 | **Planning & Research** |  | 2025-04-07 → 2025-04-29 (+22d) | 1d? → 14d | 0d → 2d |  |
| 2 | Develop Requirements Documentation |  |  | 1d? → 1d | 0d → 2d |  |
| 3 | Fit-Out Consultant Research & Engagement | 2025-04-07 → 2025-04-08 (+1d) | 2025-04-07 → 2025-04-09 (+2d) | 1d? → 2d | 0d → 2d | none → 2 |
| 4 | IT Network Contractor Research & Engagement | 2025-04-07 → 2025-04-10 (+3d) | 2025-04-07 → 2025-04-11 (+4d) | 1d? → 2d | 0d → 2d | none → 3 |
| 5 | Building Contractor Research & Engagement | 2025-04-07 → 2025-04-14 (+7d) | 2025-04-07 → 2025-04-15 (+8d) | 1d? → 2d | 0d → 2d | none → 4 |
| 6 | Submit Requirements to Resources & Request Quotes | 2025-04-07 → 2025-04-16 (+9d) | 2025-04-07 → 2025-04-16 (+9d) | 1d? → 1d | 0d → 2d | none → 5 |
| 7 | Quotes Received | 2025-04-07 → 2025-04-29 (+22d) | 2025-04-07 → 2025-04-29 (+22d) | 1d? → 1d | 0d → 2d | none → 6FS+5d |
| 8 | Planning & Research Complete | 2025-04-07 → 2025-04-29 (+22d) | 2025-04-07 → 2025-04-29 (+22d) |  | 1d → 2d | none → 7 |
| 9 | **Management Approval** | 2025-04-07 → 2025-04-30 (+23d) | 2025-04-07 → 2025-05-07 (+30d) | 1d? → 5d | 0d → 2d |  |
| 10 | Consolidate Quotes and develop proposal | 2025-04-07 → 2025-04-30 (+23d) | 2025-04-07 → 2025-05-01 (+24d) | 1d? → 2d | 0d → 2d | none → 8 |
| 11 | Develop Project Plan & Durations | 2025-04-07 → 2025-05-02 (+25d) | 2025-04-07 → 2025-05-06 (+29d) | 1d? → 2d | 0d → 2d | none → 10 |
| 12 | Submit Project Plan & Costs to Management | 2025-04-07 → 2025-05-07 (+30d) | 2025-04-07 → 2025-05-07 (+30d) | 1d? → 1d | 0d → 2d | none → 11 |
| 13 | Management Approval Received | 2025-04-07 → 2025-05-07 (+30d) | 2025-04-07 → 2025-05-07 (+30d) |  | 1d → 2d | none → 12 |
| 14 | **Refit Office** | 2025-04-07 → 2025-05-08 (+31d) | 2025-04-07 → 2025-05-28 (+51d) | 1d? → 15d |  |  |
| 15 | Appoint Resources | 2025-04-07 → 2025-05-08 (+31d) | 2025-04-07 → 2025-05-08 (+31d) | 1d? → 1d | 0d → 2d | none → 13 |
| 16 | Staff Briefing | 2025-04-07 → 2025-05-09 (+32d) | 2025-04-07 → 2025-05-09 (+32d) | 1d? → 1d | 0d → 2d | none → 15 |
| 17 | **Fit-Out Consultations** | 2025-04-07 → 2025-05-12 (+35d) | 2025-04-07 → 2025-05-15 (+38d) | 1d? → 4d | 0d → 2d |  |
| 18 | Design office space/structure plan | 2025-04-07 → 2025-05-12 (+35d) | 2025-04-07 → 2025-05-12 (+35d) | 1d? → 1d | 0d → 2d | none → 16 |
| 19 | Select & Order Carpet | 2025-04-07 → 2025-05-13 (+36d) | 2025-04-07 → 2025-05-13 (+36d) | 1d? → 1d | 0d → 7d | none → 18 |
| 20 | Select & Order Paint | 2025-04-07 → 2025-05-13 (+36d) | 2025-04-07 → 2025-05-13 (+36d) | 1d? → 1d | 0d → 7d | none → 19SS |
| 21 | Select & Order Office Furniture | 2025-04-07 → 2025-05-14 (+37d) | 2025-04-07 → 2025-05-14 (+37d) | 1d? → 1d | 0d → 7d | none → 20 |
| 22 | Select & Order digital PBX | 2025-04-07 → 2025-05-15 (+38d) | 2025-04-07 → 2025-05-15 (+38d) | 1d? → 1d | 0d → 7d | none → 21 |
| 23 | **IT consultations** | 2025-04-07 → 2025-05-12 (+35d) | 2025-04-07 → 2025-05-27 (+50d) | 1d? → 12d |  |  |
| 24 | Design IT network and phone points map | 2025-04-07 → 2025-05-12 (+35d) | 2025-04-07 → 2025-05-12 (+35d) | 1d? → 1d | 0d → 2d | none → 16 |
| 25 | Select & Order New PCs | 2025-04-07 → 2025-05-13 (+36d) | 2025-04-07 → 2025-05-13 (+36d) | 1d? → 1d | 0d → 2d | none → 24 |
| 26 | New PCs Arrive | 2025-04-07 → 2025-05-26 (+49d) | 2025-04-07 → 2025-05-26 (+49d) | 1d? → 0.5d |  | none → 25FS+10ed |
| 27 | Configure SOE on PCs | 2025-04-07 → 2025-05-26 (+49d) | 2025-04-07 → 2025-05-27 (+50d) | 1d? → 1.5d |  | none → 26 |
| 28 | **Refit Office** | 2025-04-07 → 2025-05-13 (+36d) | 2025-04-07 → 2025-05-28 (+51d) | 1d? → 12d |  |  |
| 29 | Erect New Walls | 2025-04-07 → 2025-05-13 (+36d) | 2025-04-07 → 2025-05-14 (+37d) | 1d? → 2d | 0d → 2d | none → 18, 24 |
| 30 | Gyprock, Plaster & Finish | 2025-04-07 → 2025-05-14 (+37d) | 2025-04-07 → 2025-05-15 (+38d) | 1d? → 2d | 0d → 2d | none → 29FS-1d |
| 31 | Install Network & Phone Points | 2025-04-07 → 2025-05-16 (+39d) | 2025-04-07 → 2025-05-16 (+39d) | 1d? → 1d | 0d → 2d | none → 30 |
| 32 | Painting | 2025-04-07 → 2025-05-19 (+42d) | 2025-04-07 → 2025-05-20 (+43d) | 1d? → 2d | 0d → 2d | none → 31 |
| 33 | Lay new carpets | 2025-04-07 → 2025-05-21 (+44d) | 2025-04-07 → 2025-05-21 (+44d) | 1d? → 1d | 0d → 2d | none → 32 |
| 34 | Install PBX hardware | 2025-04-07 → 2025-05-22 (+45d) | 2025-04-07 → 2025-05-22 (+45d) | 1d? → 1d | 0d → 3d | none → 22, 33 |
| 35 | Install New Furniture | 2025-04-07 → 2025-05-22 (+45d) | 2025-04-07 → 2025-05-23 (+46d) | 1d? → 2d | 0d → 2d | none → 21, 33 |
| 36 | Connect and install PCs and phones | 2025-04-07 → 2025-05-28 (+51d) | 2025-04-07 → 2025-05-28 (+51d) | 1d? → 1d |  | none → 27, 34, 35 |
| 37 | Refit Office Complete | 2025-04-07 → 2025-05-28 (+51d) | 2025-04-07 → 2025-05-28 (+51d) |  | 1d → 0d | none → 36 |
| 38 | **Office Move** | 2025-04-07 → 2025-05-12 (+35d) | 2025-04-07 → 2025-06-04 (+58d) | 1d? → 18d |  |  |
| 39 | Order packing boxes | 2025-04-07 → 2025-05-12 (+35d) | 2025-04-07 → 2025-05-12 (+35d) | 1d? → 0.5d | 0d → 12.5d | none → 16 |
| 40 | Staff Pack | 2025-04-07 → 2025-05-29 (+52d) | 2025-04-07 → 2025-05-29 (+52d) | 1d? → 1d |  | none → 37, 39 |
| 41 | Staff Move | 2025-04-07 → 2025-05-30 (+53d) | 2025-04-07 → 2025-06-02 (+56d) | 1d? → 2d |  | none → 40 |
| 42 | Office cleaning | 2025-04-07 → 2025-06-03 (+57d) | 2025-04-07 → 2025-06-04 (+58d) | 1d? → 2d |  | none → 41 |
| 43 | Office Move Complete | 2025-04-07 → 2025-06-04 (+58d) | 2025-04-07 → 2025-06-04 (+58d) |  | 1d → 0d | none → 42 |

## Version 4 (saved 2024-12-18, file Lesson 8 Printing.mpp)

Last finish 2025-06-04 → 2025-06-20 (+16d).

Changed:

| ID | Task | Start | Finish | Duration | Total float |
| --- | --- | --- | --- | --- | --- |
| 14 | **Refit Office** |  | 2025-05-28 → 2025-06-15 (+18d) | 15d → 27d |  |
| 28 | **Refit Office** | 2025-05-13 → 2025-05-17 (+4d) | 2025-05-28 → 2025-06-15 (+18d) | 12d → 20d |  |
| 29 | Erect New Walls | 2025-05-13 → 2025-05-17 (+4d) | 2025-05-14 → 2025-05-18 (+4d) |  | 2d → 0d |
| 30 | Gyprock, Plaster & Finish | 2025-05-14 → 2025-05-18 (+4d) | 2025-05-15 → 2025-05-24 (+9d) |  | 2d → 0d |
| 31 | Install Network & Phone Points | 2025-05-16 → 2025-05-25 (+9d) | 2025-05-16 → 2025-05-25 (+9d) |  | 2d → 0d |
| 32 | Painting | 2025-05-19 → 2025-05-31 (+12d) | 2025-05-20 → 2025-06-01 (+12d) |  | 2d → 0d |
| 33 | Lay new carpets | 2025-05-21 → 2025-06-07 (+17d) | 2025-05-21 → 2025-06-07 (+17d) |  | 2d → 0d |
| 34 | Install PBX hardware | 2025-05-22 → 2025-06-08 (+17d) | 2025-05-22 → 2025-06-08 (+17d) |  | 3d → 1d |
| 35 | Install New Furniture | 2025-05-22 → 2025-06-08 (+17d) | 2025-05-23 → 2025-06-14 (+22d) |  | 2d → 0d |
| 36 | Connect and install PCs and phones | 2025-05-28 → 2025-06-15 (+18d) | 2025-05-28 → 2025-06-15 (+18d) |  |  |
| 37 | Refit Office Complete | 2025-05-28 → 2025-06-15 (+18d) | 2025-05-28 → 2025-06-15 (+18d) |  |  |
| 38 | **Office Move** |  | 2025-06-04 → 2025-06-20 (+16d) | 18d → 30d |  |
| 40 | Staff Pack | 2025-05-29 → 2025-06-16 (+18d) | 2025-05-29 → 2025-06-16 (+18d) |  |  |
| 41 | Staff Move | 2025-05-30 → 2025-06-17 (+18d) | 2025-06-02 → 2025-06-18 (+16d) |  |  |
| 42 | Office cleaning | 2025-06-03 → 2025-06-19 (+16d) | 2025-06-04 → 2025-06-20 (+16d) |  |  |
| 43 | Office Move Complete | 2025-06-04 → 2025-06-20 (+16d) | 2025-06-04 → 2025-06-20 (+16d) |  |  |

## Version 5 (saved 2024-12-18, file Lesson 9 Levelling.mpp)

Last finish stays 2025-06-20.

Changed:

| ID | Task | Other |
| --- | --- | --- |
| 2 | Develop Requirements Documentation | resources none → Project Manager |
| 3 | Fit-Out Consultant Research & Engagement | resources none → Project Manager |
| 4 | IT Network Contractor Research & Engagement | resources none → Project Manager |
| 5 | Building Contractor Research & Engagement | resources none → Project Manager |
| 6 | Submit Requirements to Resources & Request Quotes | resources none → Project Manager |
| 7 | Quotes Received | resources none → Project Manager |
| 10 | Consolidate Quotes and develop proposal | resources none → Project Manager |
| 11 | Develop Project Plan & Durations | resources none → Project Manager |
| 12 | Submit Project Plan & Costs to Management | resources none → Management; Project Manager |
| 15 | Appoint Resources | resources none → Project Manager |
| 16 | Staff Briefing | resources none → Project Manager; Staff [700%] |
| 18 | Design office space/structure plan | resources none → Fit-out Consultant; Project Manager |
| 19 | Select & Order Carpet | resources none → Fit-out Consultant; Project Manager |
| 20 | Select & Order Paint | resources none → Fit-out Consultant; Project Manager |
| 21 | Select & Order Office Furniture | resources none → Fit-out Consultant; Project Manager |
| 22 | Select & Order digital PBX | resources none → Fit-out Consultant; Project Manager |
| 24 | Design IT network and phone points map | resources none → IT Consultant; Project Manager |
| 25 | Select & Order New PCs | resources none → Project Manager |
| 26 | New PCs Arrive | resources none → Project Manager |
| 27 | Configure SOE on PCs | resources none → IT Consultant |
| 29 | Erect New Walls | resources none → Carpenter [200%] |
| 30 | Gyprock, Plaster & Finish | resources none → Plastering Contractor |
| 31 | Install Network & Phone Points | resources none → IT Consultant |
| 32 | Painting | resources none → Painter |
| 33 | Lay new carpets | resources none → Carpet Contractor |
| 34 | Install PBX hardware | resources none → IT Consultant |
| 35 | Install New Furniture | resources none → Labourer |
| 36 | Connect and install PCs and phones | resources none → IT Consultant |
| 39 | Order packing boxes | resources none → Project Manager |
| 40 | Staff Pack | resources none → Project Manager; Staff [2000%] |
| 41 | Staff Move | resources none → Staff [2000%]; Labourer |
| 42 | Office cleaning | resources none → Cleaner [200%] |

## Version 6 (saved 2024-12-18, file Lesson 9 Resources.mpp)

Last finish stays 2025-06-20.

Changed:

| ID | Task | Other |
| --- | --- | --- |
| 2 | Develop Requirements Documentation | resources Project Manager → none |
| 3 | Fit-Out Consultant Research & Engagement | resources Project Manager → none |
| 4 | IT Network Contractor Research & Engagement | resources Project Manager → none |
| 5 | Building Contractor Research & Engagement | resources Project Manager → none |
| 6 | Submit Requirements to Resources & Request Quotes | resources Project Manager → none |
| 7 | Quotes Received | resources Project Manager → none |
| 10 | Consolidate Quotes and develop proposal | resources Project Manager → none |
| 11 | Develop Project Plan & Durations | resources Project Manager → none |
| 12 | Submit Project Plan & Costs to Management | resources Management; Project Manager → none |
| 15 | Appoint Resources | resources Project Manager → none |
| 16 | Staff Briefing | resources Project Manager; Staff [700%] → none |
| 18 | Design office space/structure plan | resources Fit-out Consultant; Project Manager → none |
| 19 | Select & Order Carpet | resources Fit-out Consultant; Project Manager → none |
| 20 | Select & Order Paint | resources Fit-out Consultant; Project Manager → none |
| 21 | Select & Order Office Furniture | resources Fit-out Consultant; Project Manager → none |
| 22 | Select & Order digital PBX | resources Fit-out Consultant; Project Manager → none |
| 24 | Design IT network and phone points map | resources IT Consultant; Project Manager → none |
| 25 | Select & Order New PCs | resources Project Manager → none |
| 26 | New PCs Arrive | resources Project Manager → none |
| 27 | Configure SOE on PCs | resources IT Consultant → none |
| 29 | Erect New Walls | resources Carpenter [200%] → none |
| 30 | Gyprock, Plaster & Finish | resources Plastering Contractor → none |
| 31 | Install Network & Phone Points | resources IT Consultant → none |
| 32 | Painting | resources Painter → none |
| 33 | Lay new carpets | resources Carpet Contractor → none |
| 34 | Install PBX hardware | resources IT Consultant → none |
| 35 | Install New Furniture | resources Labourer → none |
| 36 | Connect and install PCs and phones | resources IT Consultant → none |
| 39 | Order packing boxes | resources Project Manager → none |
| 40 | Staff Pack | resources Project Manager; Staff [2000%] → none |
| 41 | Staff Move | resources Staff [2000%]; Labourer → none |
| 42 | Office cleaning | resources Cleaner [200%] → none |

## Version 7 (saved 2024-12-18, file Lesson 10 Costs.mpp)

Last finish stays 2025-06-20.

Changed:

| ID | Task | Start | Finish | Duration | Total float | Predecessors | Other |
| --- | --- | --- | --- | --- | --- | --- | --- |
| 2 | Develop Requirements Documentation |  |  |  |  |  | resources none → Project Manager |
| 3 | Fit-Out Consultant Research & Engagement |  |  |  |  |  | resources none → Project Manager |
| 4 | IT Network Contractor Research & Engagement |  |  |  |  |  | resources none → Project Manager |
| 5 | Building Contractor Research & Engagement |  |  |  |  |  | resources none → Project Manager |
| 6 | Submit Requirements to Resources & Request Quotes |  |  |  |  |  | resources none → Project Manager |
| 7 | Quotes Received |  |  |  |  |  | resources none → Project Manager |
| 10 | Consolidate Quotes and develop proposal |  |  |  |  |  | resources none → Project Manager |
| 11 | Develop Project Plan & Durations |  |  |  |  |  | resources none → Project Manager |
| 12 | Submit Project Plan & Costs to Management |  |  |  |  |  | resources none → Management; Project Manager |
| 15 | Appoint Resources |  |  |  |  |  | resources none → Project Manager |
| 16 | Staff Briefing |  |  |  |  |  | resources none → Project Manager; Staff [700%] |
| 17 | **Fit-Out Consultations** |  | 2025-05-15 → 2025-05-16 (+1d) | 4d → 5d |  |  |  |
| 18 | Design office space/structure plan |  |  |  |  |  | resources none → Fit-out Consultant; Project Manager |
| 19 | Select & Order Carpet |  |  |  | 17d → 16d |  | resources none → Fit-out Consultant; Project Manager |
| 20 | Select & Order Paint | 2025-05-13 → 2025-05-14 (+1d) | 2025-05-13 → 2025-05-14 (+1d) |  | 17d → 16d | 19SS → 19 | resources none → Fit-out Consultant; Project Manager |
| 21 | Select & Order Office Furniture | 2025-05-14 → 2025-05-15 (+1d) | 2025-05-14 → 2025-05-15 (+1d) |  | 17d → 16d |  | resources none → Fit-out Consultant; Project Manager |
| 22 | Select & Order digital PBX | 2025-05-15 → 2025-05-16 (+1d) | 2025-05-15 → 2025-05-16 (+1d) |  | 21d → 20d |  | resources none → Fit-out Consultant; Project Manager |
| 24 | Design IT network and phone points map |  |  |  |  |  | resources none → IT Consultant |
| 25 | Select & Order New PCs |  |  |  |  |  | resources none → IT Consultant |
| 26 | New PCs Arrive |  |  |  |  |  | resources none → Project Manager |
| 27 | Configure SOE on PCs |  |  |  |  |  | resources none → IT Consultant |
| 29 | Erect New Walls |  |  |  |  |  | resources none → Carpenter [200%] |
| 30 | Gyprock, Plaster & Finish |  |  |  |  |  | resources none → Plastering Contractor |
| 31 | Install Network & Phone Points |  |  |  |  |  | resources none → IT Consultant |
| 32 | Painting |  |  |  |  |  | resources none → Painter |
| 33 | Lay new carpets |  |  |  |  |  | resources none → Carpet Contractor |
| 34 | Install PBX hardware |  |  |  |  |  | resources none → IT Consultant |
| 35 | Install New Furniture |  |  |  |  |  | resources none → Labourer |
| 36 | Connect and install PCs and phones |  |  |  |  |  | resources none → IT Consultant |
| 39 | Order packing boxes |  |  |  |  |  | resources none → Admin Assistant |
| 40 | Staff Pack |  |  |  |  |  | resources none → Project Manager; Staff [2000%] |
| 41 | Staff Move |  |  |  |  |  | resources none → Staff [2000%]; Labourer |
| 42 | Office cleaning |  |  |  |  |  | resources none → Cleaner [200%] |

## Version 8 (data date 2025-05-19, saved 2024-12-18, file Office Renovation completed.mpp)

Last finish 2025-06-20 → 2025-06-27 (+7d). Complete tasks 0 → 11.

Added:

| ID | Task | Duration | Start | Finish | Predecessors |
| --- | --- | --- | --- | --- | --- |
| 30 | Variation #1 - Fit out and install new reception area | 2d | 2025-05-24 | 2025-05-25 | 29 |

Changed:

| ID | Task | Start | Finish | Duration | Complete | Total float | Predecessors | Other |
| --- | --- | --- | --- | --- | --- | --- | --- | --- |
| 1 | **Planning & Research** | 2025-04-07 A | 2025-04-29 A | 14d → 13d | 0% → 100% | 4d → none |  | baseline start none → 2025-04-07; baseline finish none → 2025-04-29 |
| 2 | Develop Requirements Documentation | 2025-04-07 A | 2025-04-07 A |  | 0% → 100% | 4d → none |  | baseline start none → 2025-04-07; baseline finish none → 2025-04-07 |
| 3 | Fit-Out Consultant Research & Engagement | 2025-04-08 A | 2025-04-09 A |  | 0% → 100% | 4d → none |  | baseline start none → 2025-04-08; baseline finish none → 2025-04-09 |
| 4 | IT Network Contractor Research & Engagement | 2025-04-10 A | 2025-04-11 A |  | 0% → 100% | 4d → none |  | baseline start none → 2025-04-10; baseline finish none → 2025-04-11 |
| 5 | Building Contractor Research & Engagement | 2025-04-14 → 2025-04-16 A (+2d) | 2025-04-15 → 2025-04-17 A (+2d) |  | 0% → 100% | 4d → none |  | baseline start none → 2025-04-16; baseline finish none → 2025-04-17 |
| 6 | Submit Requirements to Resources & Request Quotes | 2025-04-16 → 2025-04-18 A (+2d) | 2025-04-16 → 2025-04-18 A (+2d) |  | 0% → 100% | 4d → none |  | baseline start none → 2025-04-18; baseline finish none → 2025-04-18 |
| 7 | Quotes Received | 2025-04-29 → 2025-04-28 A (-1d) | 2025-04-29 → 2025-04-28 A (-1d) |  | 0% → 100% | 4d → none |  | baseline start none → 2025-04-28; baseline finish none → 2025-04-28 |
| 8 | Planning & Research Complete | 2025-04-29 A | 2025-04-29 A |  | 0% → 100% | 4d → none |  | baseline start none → 2025-04-29; baseline finish none → 2025-04-29 |
| 9 | **Management Approval** | 2025-04-30 → 2025-04-29 A (-1d) | 2025-05-07 → 2025-05-13 A (+6d) | 5d → 9d | 0% → 100% | 4d → none |  | baseline start none → 2025-04-29; baseline finish none → 2025-05-13 |
| 10 | Consolidate Quotes and develop proposal | 2025-04-30 → 2025-04-29 A (-1d) | 2025-05-01 → 2025-04-30 A (-1d) |  | 0% → 100% | 4d → none |  | baseline start none → 2025-04-29; baseline finish none → 2025-04-30 |
| 11 | Develop Project Plan & Durations | 2025-05-02 → 2025-05-01 A (-1d) | 2025-05-06 → 2025-05-02 A (-4d) |  | 0% → 100% | 4d → none |  | baseline start none → 2025-05-01; baseline finish none → 2025-05-02 |
| 12 | Submit Project Plan & Costs to Management | 2025-05-07 → 2025-05-06 A (-1d) | 2025-05-07 → 2025-05-06 A (-1d) |  | 0% → 100% | 4d → none |  | baseline start none → 2025-05-06; baseline finish none → 2025-05-06 |
| 13 | Management Approval Received | 2025-05-07 → 2025-05-13 A (+6d) | 2025-05-07 → 2025-05-13 A (+6d) |  | 0% → 100% | 4d → none |  | baseline start none → 2025-05-13; baseline finish none → 2025-05-13 |
| 14 | **Refit Office** | 2025-05-08 → 2025-05-13 (+5d) | 2025-06-15 → 2025-06-21 (+6d) | 27d → 29d |  |  |  | baseline start none → 2025-05-13; baseline finish none → 2025-06-21 |
| 15 | Appoint Resources | 2025-05-08 → 2025-05-13 (+5d) | 2025-05-08 → 2025-05-13 (+5d) |  |  | 4d → 1d |  | baseline start none → 2025-05-13; baseline finish none → 2025-05-13 |
| 16 | Staff Briefing | 2025-05-09 → 2025-05-14 (+5d) | 2025-05-09 → 2025-05-14 (+5d) |  |  | 4d → 1d |  | baseline start none → 2025-05-14; baseline finish none → 2025-05-14 |
| 17 | **Fit-Out Consultations** | 2025-05-12 → 2025-05-15 (+3d) | 2025-05-16 → 2025-05-21 (+5d) |  |  | 4d → 1d |  | baseline start none → 2025-05-15; baseline finish none → 2025-05-21 |
| 18 | Design office space/structure plan | 2025-05-12 → 2025-05-15 (+3d) | 2025-05-12 → 2025-05-15 (+3d) |  |  | 4d → 1d |  | baseline start none → 2025-05-15; baseline finish none → 2025-05-15 |
| 19 | Select & Order Carpet | 2025-05-13 → 2025-05-16 (+3d) | 2025-05-13 → 2025-05-16 (+3d) |  |  | 16d → 22d |  | baseline start none → 2025-05-16; baseline finish none → 2025-05-16 |
| 20 | Select & Order Paint | 2025-05-14 → 2025-05-19 (+5d) | 2025-05-14 → 2025-05-19 (+5d) |  |  | 16d → 22d |  | baseline start none → 2025-05-19; baseline finish none → 2025-05-19 |
| 21 | Select & Order Office Furniture | 2025-05-15 → 2025-05-20 (+5d) | 2025-05-15 → 2025-05-20 (+5d) |  |  | 16d → 22d |  | baseline start none → 2025-05-20; baseline finish none → 2025-05-20 |
| 22 | Select & Order digital PBX | 2025-05-16 → 2025-05-21 (+5d) | 2025-05-16 → 2025-05-21 (+5d) |  |  | 20d → 22d |  | baseline start none → 2025-05-21; baseline finish none → 2025-05-21 |
| 23 | **IT consultations** | 2025-05-12 → 2025-05-15 (+3d) | 2025-05-27 → 2025-05-28 (+1d) | 12d → 10d |  | 4d → 1d |  | baseline start none → 2025-05-15; baseline finish none → 2025-05-28 |
| 24 | Design IT network and phone points map | 2025-05-12 → 2025-05-15 (+3d) | 2025-05-12 → 2025-05-15 (+3d) |  |  | 4d → 1d |  | baseline start none → 2025-05-15; baseline finish none → 2025-05-15 |
| 25 | Select & Order New PCs | 2025-05-13 → 2025-05-16 (+3d) | 2025-05-13 → 2025-05-16 (+3d) |  |  | 13d → 15d |  | baseline start none → 2025-05-16; baseline finish none → 2025-05-16 |
| 26 | New PCs Arrive | 2025-05-26 → 2025-05-27 (+1d) | 2025-05-26 → 2025-05-27 (+1d) |  |  | 13d → 17d |  | baseline start none → 2025-05-27; baseline finish none → 2025-05-27 |
| 27 | Configure SOE on PCs | 2025-05-26 → 2025-05-27 (+1d) | 2025-05-27 → 2025-05-28 (+1d) |  |  | 13d → 17d |  | baseline start none → 2025-05-27; baseline finish none → 2025-05-28 |
| 28 | **Refit Office** |  | 2025-06-15 → 2025-06-21 (+6d) | 20d → 25d |  |  |  | baseline start none → 2025-05-17; baseline finish none → 2025-06-21 |
| 29 | Erect New Walls |  |  |  |  | 0d → 1d |  | baseline start none → 2025-05-17; baseline finish none → 2025-05-18 |
| 31 | Gyprock, Plaster & Finish | 2025-05-18 → 2025-05-31 (+13d) | 2025-05-24 → 2025-05-31 (+7d) | 2d → 1d |  | 0d → 1d | 29FS-1d → 29FS-1d, 30 | baseline start none → 2025-05-31; baseline finish none → 2025-05-31 |
| 32 | Install Network & Phone Points | 2025-05-25 → 2025-06-01 (+7d) | 2025-05-25 → 2025-06-01 (+7d) |  |  | 0d → 1d |  | baseline start none → 2025-06-01; baseline finish none → 2025-06-01 |
| 33 | Painting | 2025-05-31 → 2025-06-07 (+7d) | 2025-06-01 → 2025-06-08 (+7d) |  |  | 0d → 1d |  | baseline start none → 2025-06-07; baseline finish none → 2025-06-08 |
| 34 | Lay new carpets | 2025-06-07 → 2025-06-14 (+7d) | 2025-06-07 → 2025-06-14 (+7d) |  |  | 0d → 1d |  | baseline start none → 2025-06-14; baseline finish none → 2025-06-14 |
| 35 | Install PBX hardware | 2025-06-08 → 2025-06-15 (+7d) | 2025-06-08 → 2025-06-15 (+7d) |  |  |  |  | baseline start none → 2025-06-15; baseline finish none → 2025-06-15 |
| 36 | Install New Furniture | 2025-06-08 → 2025-06-15 (+7d) | 2025-06-14 → 2025-06-15 (+1d) | 2d → 1d |  | 0d → 1d |  | baseline start none → 2025-06-15; baseline finish none → 2025-06-15 |
| 37 | Connect and install PCs and phones | 2025-06-15 → 2025-06-21 (+6d) | 2025-06-15 → 2025-06-21 (+6d) |  |  | 0d → 1d |  | baseline start none → 2025-06-21; baseline finish none → 2025-06-21 |
| 38 | Refit Office Complete | 2025-06-15 → 2025-06-21 (+6d) | 2025-06-15 → 2025-06-21 (+6d) |  |  |  |  | baseline start none → 2025-06-21; baseline finish none → 2025-06-21 |
| 39 | **Office Move** | 2025-05-12 → 2025-05-15 (+3d) | 2025-06-20 → 2025-06-27 (+7d) | 30d → 32d |  |  |  | baseline start none → 2025-05-15; baseline finish none → 2025-06-27 |
| 40 | Order packing boxes | 2025-05-12 → 2025-05-15 (+3d) | 2025-05-12 → 2025-05-15 (+3d) |  |  | 24.5d → 26.5d |  | baseline start none → 2025-05-15; baseline finish none → 2025-05-15 |
| 41 | Staff Pack | 2025-06-16 → 2025-06-23 (+7d) | 2025-06-16 → 2025-06-23 (+7d) |  |  |  |  | baseline start none → 2025-06-23; baseline finish none → 2025-06-23 |
| 42 | Staff Move | 2025-06-17 → 2025-06-24 (+7d) | 2025-06-18 → 2025-06-25 (+7d) |  |  |  |  | baseline start none → 2025-06-24; baseline finish none → 2025-06-25 |
| 43 | Office cleaning | 2025-06-19 → 2025-06-26 (+7d) | 2025-06-20 → 2025-06-27 (+7d) |  |  |  |  | baseline start none → 2025-06-26; baseline finish none → 2025-06-27 |
| 44 | Office Move Complete | 2025-06-20 → 2025-06-27 (+7d) | 2025-06-20 → 2025-06-27 (+7d) |  |  |  |  | baseline start none → 2025-06-27; baseline finish none → 2025-06-27 |
